# Toroid Charge Monitor Schedule

Schedule from MS Project, 2006-03-21 to 2006-09-26.

## Calendars

- Standard: Mon-Fri 08:00-12:00, 13:00-17:00; Sat-Sun off.

## Resources

| Resource |
| --- |
| mcecere |
| m |
| FPGAeng |
| peng |
| LayoutEng |

## Schedule

| ID | WBS | Task | Type | Duration | Start | Finish | Predecessors | Baseline start | Baseline finish | Baseline duration | Total slack | Free slack | Constraint | Resources | Work |
| --- | --- | --- | --- | --- | --- | --- | --- | --- | --- | --- | --- | --- | --- | --- | --- |
| 3 | 1 | **Toroid Charge Measurement Project** |  | 136d? | 2006-03-21 | 2006-09-26 |  | 1999-04-01 | 1999-04-01 | 1d | 0d |  |  |  | 2528h |
| 4 | 1.1 | **System Design, Approvals, & Prototyping** |  | 63d? | 2006-03-21 | 2006-06-15 |  | 1999-04-01 | 2003-01-03 | 982d | 12d |  |  |  | 896h |
| 5 | 1.1.1 | Requirements & Specifications |  | 18d | 2006-04-03 | 2006-04-26 |  | 1999-04-01 | 2001-02-28 | 500d | 109d |  | finish no earlier than 2006-04-26 | mcecere | 144h |
| 6 | 1.1.2 | Evaluate Design Performance Metrics |  | 11d | 2006-04-12 | 2006-04-26 |  | 2000-03-03 | 2002-01-31 | 500d | 109d |  | finish no earlier than 2006-04-26 | mcecere | 88h |
| 7 | 1.1.3 | Documentation & CDR Prep |  | 47d | 2006-03-21 | 2006-05-24 |  | 2001-02-05 | 2003-01-03 | 500d | 20d | 0d | finish no earlier than 2006-05-24 | mcecere | 376h |
| 8 | 1.1.4 | CDR Complete | milestone | 0d | 2006-05-24 | 2006-05-24 | 7 | 2002-10-04 | 2002-10-04 | 0d | 20d | 0d | start no earlier than 2006-05-11 | mcecere |  |
| 10 | 1.1.5 | **Hardware Block Diagrams** |  | 15d | 2006-05-25 | 2006-06-14 | 8 |  |  |  | 12d |  |  |  | 240h |
| 11 | 1.1.5.1 | Analog Front End Block Design |  | 15d | 2006-05-25 | 2006-06-14 |  |  |  |  | 20d | 0d | finish no earlier than 2006-06-14 | mcecere | 120h |
| 12 | 1.1.5.2 | Microncontroller ADC/DAC Block Design |  | 10d | 2006-05-25 | 2006-06-07 |  |  |  |  | 53d | 0d | finish no earlier than 2006-05-24 | FPGAeng | 80h |
| 13 | 1.1.5.3 | MPS Block Design |  | 5d | 2006-05-25 | 2006-05-31 | 11 | 1999-04-01 | 1999-04-01 | 1d | 58d | 5d | finish no earlier than 2006-05-31 | mcecere | 40h |
| 14 | 1.1.6 | **micro Software Block Diagram** |  | 6d? | 2006-06-08 | 2006-06-15 |  |  |  |  | 65d |  |  |  | 48h |
| 15 | 1.1.6.1 | Signal Processing Block Diagram |  | 6d? | 2006-06-08 | 2006-06-15 | 12 |  |  |  | 73d |  | finish no earlier than 2006-06-15 | peng | 48h |
| 17 | 1.2 | **PDR and FDR Preperation** |  | 50d? | 2006-05-25 | 2006-08-02 |  |  |  |  | 39d |  |  |  | 400h |
| 18 | 1.2.1 | Documentation & PDR Prep |  | 25d | 2006-05-25 | 2006-06-28 | 8 | 2001-02-05 | 2003-01-03 | 500d | 39d | 0d | finish no earlier than 2006-06-28 | mcecere | 200h |
| 19 | 1.2.2 | PDR Complete | milestone | 0d | 2006-06-28 | 2006-06-28 | 18 | 2002-10-04 | 2002-10-04 | 0d | 39d | 0d |  | mcecere |  |
| 20 | 1.2.3 | Implement Changes from PDR |  | 15d? | 2006-06-29 | 2006-07-19 | 19 |  |  |  | 39d | 0d | finish no earlier than 2006-07-19 | mcecere | 120h |
| 21 | 1.2.4 | Documentation & FDR Prep |  | 10d | 2006-07-20 | 2006-08-02 | 20 | 2001-02-05 | 2003-01-03 | 500d | 39d | 0d | finish no earlier than 2006-08-02 | mcecere | 80h |
| 22 | 1.2.5 | FDR Complete | milestone | 0d | 2006-08-02 | 2006-08-02 | 21 | 2001-02-05 | 2003-01-03 | 500d | 39d |  |  | mcecere |  |
| 23 | 1.3 | **Hardware Schematic Capture** |  | 26d? | 2006-06-08 | 2006-07-13 |  |  |  |  | 17d |  |  |  | 584h |
| 24 | 1.3.1 | Analog Front End Schematic Capture |  | 21d? | 2006-06-15 | 2006-07-13 | 11 |  |  |  | 20d | 0d | finish no earlier than 2006-07-06 | mcecere | 168h |
| 25 | 1.3.2 | micro/ADC/DAC Schematic Capture |  | 26d? | 2006-06-08 | 2006-07-13 | 12 |  |  |  | 53d |  | finish no earlier than 2006-07-13 | FPGAeng | 208h |
| 26 | 1.3.3 | MPS Schematic Capture |  | 26d? | 2006-06-08 | 2006-07-13 | 13 |  |  |  | 45d |  | finish no earlier than 2006-07-13 | mcecere | 208h |
| 29 | 1.4 | **Software Development** |  | 31d? | 2006-07-14 | 2006-08-25 |  |  |  |  | 14d |  |  |  | 248h |
| 30 | 1.4.1 | micro-controller Software |  | 31d? | 2006-07-14 | 2006-08-25 | 24 |  |  |  | 14d |  | finish no earlier than 2006-07-20 | peng | 248h |

| ID | WBS | Task | Duration | Start | Finish | Predecessors | Total slack | Free slack | Constraint | Resources | Work |
| --- | --- | --- | --- | --- | --- | --- | --- | --- | --- | --- | --- |
| 32 | 1.5 | **Board Hardware Development** | 45d? | 2006-07-14 | 2006-09-14 |  | 8d |  |  |  | 400h |
| 33 | 1.5.1 | Board Layout | 11d? | 2006-07-14 | 2006-07-28 | 24 | 20d | 0d | finish no earlier than 2006-07-28 | LayoutEng | 88h |
| 34 | 1.5.2 | Board Manufacture | 9d? | 2006-07-31 | 2006-08-10 | 33 | 20d | 0d | finish no earlier than 2006-07-26 |  |  |
| 35 | 1.5.3 | Stuff Board | 6d? | 2006-08-11 | 2006-08-18 | 34 | 20d | 0d | finish no earlier than 2006-08-04 |  |  |
| 36 | 1.5.4 | Power Up and Analog Circuit Test | 7d? | 2006-08-21 | 2006-08-29 | 35 | 20d |  | finish no earlier than 2006-08-29 | mcecere | 56h |
| 37 | 1.5.5 | Software Download and Test | 16d? | 2006-08-24 | 2006-09-14 |  | 8d |  | start no earlier than 2006-08-24 | mcecere; FPGAeng | 256h |
| 39 | 1.6 | **System Integration** | 25d? | 2006-08-23 | 2006-09-26 |  | 0d |  |  |  | 400h |
| 40 | 1.6.1 | EVR Trigger Testing | 8d? | 2006-08-23 | 2006-09-01 |  | 0d |  | finish no earlier than 2006-09-01 |  | 128h |
| 41 | 1.6.2 | Full Test Bench Testout | 17d? | 2006-09-04 | 2006-09-26 |  | 0d |  | finish no earlier than 2006-09-26 | peng | 272h |
| 42 | 1.6.3 | Line Test with Live Beam | 4d? | 2006-09-21 | 2006-09-26 | 41 | 0d |  | start no earlier than 2006-09-21 |  |  |
